# Civil work in Boilder Foundation

Schedule from Primavera P6, 2020-11-10 to 2020-12-19, data date 2020-11-10, costs in PKR.
Must finish by 2020-12-19

## Calendars

- Boiler Calender: Mon-Thu 07:00-17:00; Fri 07:00-18:00; Sat-Sun 07:00-17:00. Exceptions (off unless hours are given): 2020-11-13 08:00-16:00, 2020-11-20 08:00-16:00, 2020-11-27 08:00-16:00.

## Resources

| Resource | Group | Unit | Rate |
| --- | --- | --- | --- |
| Cost Loading | material | PKR | 1 |

## Schedule

| ID | WBS | Activity | Type | Duration | Start | Finish | Predecessors | Total float | Free float | Resources | Cost |
| --- | --- | --- | --- | --- | --- | --- | --- | --- | --- | --- | --- |
|  | 1 | **Preliminary work** |  |  | 2020-11-10 | 2020-11-12 |  |  |  |  |  |
| A1000 |  | Project Start | milestone | 0d | 2020-11-10 | 2020-11-10 |  | -0.3d | 0d |  |  |
| A1010 |  | Project Moblization |  | 2d | 2020-11-10 | 2020-11-11 | A1000 | -0.3d | 0d |  |  |
| A1020 |  | Initial Survey |  | 1d | 2020-11-12 | 2020-11-12 | A1010 | -0.3d | 0d |  |  |
|  | 2 | **Civil Work** |  |  | 2020-11-13 | 2020-12-19 |  |  |  |  |  |
|  | 7 | **Survey Work** |  |  | 2020-11-13 | 2020-11-17 |  |  |  |  |  |
| A1030 |  | Layout for start of Work |  | 4d | 2020-11-13 | 2020-11-17 | A1020 | -0.3d | 0d |  |  |
|  | 1 | **Front Shaft** |  |  | 2020-11-17 | 2020-12-11 |  |  |  |  |  |
| B1000 |  | Excavation |  | 2d | 2020-11-17 | 2020-11-19 | A1030 | -0.3d | 0d | Cost Loading [8700 PKR] | 8,700 |
| B1010 |  | P.C.C Concrete 1:4:8 |  | 3d | 2020-11-19 | 2020-11-22 | B1000 | 7.7d | 0d | Cost Loading [6825 PKR] | 6,825 |
| B1020 |  | Reinforcement 60 Grade |  | 4d | 2020-11-22 | 2020-11-26 | B1010 | 7.7d | 0d | Cost Loading [74250 PKR] | 74,250 |
| B1030 |  | Form Work |  | 3d | 2020-11-26 | 2020-11-29 | B1020 | 7.7d | 0d | Cost Loading [36550 PKR] | 36,550 |
| B1040 |  | Footing Concrete R.C.C (C20) |  | 3d | 2020-11-29 | 2020-12-02 | B1030 | 7.7d | 0d | Cost Loading [13920 PKR] | 13,920 |
| B1050 |  | Foundation beam R.C.C (C20) |  | 3d | 2020-12-02 | 2020-12-05 | B1040 | 7.7d | 0d | Cost Loading [17760 PKR] | 17,760 |
| B1060 |  | Backfilling |  | 3d | 2020-12-05 | 2020-12-08 | B1050 | 10.7d | 11d | Cost Loading [7740 PKR] | 7,740 |
| B1070 |  | Flooring R.C.C (C20) |  | 3d | 2020-12-05 | 2020-12-08 | B1050 | 7.7d | 0d | Cost Loading [8000 PKR] | 8,000 |
| B1080 |  | Bitumen Coating |  | 3d | 2020-12-08 | 2020-12-11 | B1070 | 7.7d | 8d | Cost Loading [17200 PKR] | 17,200 |
|  | 2 | **Reducer Section 3-3** |  |  | 2020-11-17 | 2020-12-11 |  |  |  |  |  |
| B1090 |  | Excavation |  | 2d | 2020-11-17 | 2020-11-19 | B1000 SS | 7.7d | 0d | Cost Loading [4350 PKR] | 4,350 |
| B1100 |  | P.C.C Concrete 1:4:8 |  | 3d | 2020-11-19 | 2020-11-22 | B1090 | 7.7d | 0d | Cost Loading [3412.5 PKR] | 3,412.5 |
| B1110 |  | Reinforcement 60 Grade |  | 4d | 2020-11-22 | 2020-11-26 | B1100 | 7.7d | 0d | Cost Loading [37125 PKR] | 37,125 |
| B1120 |  | Form Work |  | 3d | 2020-11-26 | 2020-11-29 | B1110 | 7.7d | 0d | Cost Loading [18275 PKR] | 18,275 |
| B1130 |  | Footing Concrete R.C.C (C20) |  | 3d | 2020-11-29 | 2020-12-02 | B1120 | 7.7d | 0d | Cost Loading [6960 PKR] | 6,960 |
| B1140 |  | Foundation beam R.C.C (C20) |  | 3d | 2020-12-02 | 2020-12-05 | B1130 | 7.7d | 0d | Cost Loading [8880 PKR] | 8,880 |
| B1150 |  | Backfilling |  | 3d | 2020-12-05 | 2020-12-08 | B1140 | 10.7d | 11d | Cost Loading [3870 PKR] | 3,870 |
| B1160 |  | Flooring R.C.C (C20) |  | 3d | 2020-12-05 | 2020-12-08 | B1140 | 7.7d | 0d | Cost Loading [4000 PKR] | 4,000 |
| B1170 |  | Bitumen Coating |  | 3d | 2020-12-08 | 2020-12-11 | B1160 | 7.7d | 8d | Cost Loading [8600 PKR] | 8,600 |

| ID | WBS | Activity | Duration | Start | Finish | Predecessors | Total float | Free float | Resources | Cost |
| --- | --- | --- | --- | --- | --- | --- | --- | --- | --- | --- |
|  | 3 | **Section 2-2** |  | 2020-11-17 | 2020-12-11 |  |  |  |  |  |
| B1180 |  | Excavation | 2d | 2020-11-17 | 2020-11-19 | B1000 SS | 7.7d | 0d | Cost Loading [17400 PKR] | 17,400 |
| B1190 |  | P.C.C Concrete 1:4:8 | 3d | 2020-11-19 | 2020-11-22 | B1180 | 7.7d | 0d | Cost Loading [13650 PKR] | 13,650 |
| B1200 |  | Reinforcement 60 Grade | 3d | 2020-11-22 | 2020-11-25 | B1190 | 7.7d | 0d | Cost Loading [148500 PKR] | 148,500 |
| B1210 |  | Form Work | 3d | 2020-11-25 | 2020-11-28 | B1200 | 7.7d | 0d | Cost Loading [73100 PKR] | 73,100 |
| B1220 |  | Footing Concrete R.C.C (C20) | 3d | 2020-11-28 | 2020-12-01 | B1210 | 7.7d | 0d | Cost Loading [27840 PKR] | 27,840 |
| B1230 |  | Foundation beam R.C.C (C20) | 4d | 2020-12-01 | 2020-12-05 | B1220 | 7.7d | 0d | Cost Loading [35520 PKR] | 35,520 |
| B1240 |  | Backfilling | 3d | 2020-12-05 | 2020-12-08 | B1230 | 10.7d | 11d | Cost Loading [15480 PKR] | 15,480 |
| B1250 |  | Flooring R.C.C (C20) | 3d | 2020-12-05 | 2020-12-08 | B1230 | 7.7d | 0d | Cost Loading [16000 PKR] | 16,000 |
| B1260 |  | Bitumen Coating | 3d | 2020-12-08 | 2020-12-11 | B1250 | 7.7d | 8d | Cost Loading [34400 PKR] | 34,400 |
|  | 4 | **Section 6-6** |  | 2020-11-17 | 2020-12-19 |  |  |  |  |  |
| B1270 |  | Excavation | 4d | 2020-11-17 | 2020-11-21 | B1000 SS | -0.3d | 0d | Cost Loading [21750 PKR] | 21,750 |
| B1280 |  | P.C.C Concrete 1:4:8 | 4d | 2020-11-21 | 2020-11-25 | B1270 | -0.3d | 0d | Cost Loading [17062.5 PKR] | 17,062.5 |
| B1290 |  | Reinforcement 60 Grade | 4d | 2020-11-25 | 2020-11-29 | B1280 | -0.3d | 0d | Cost Loading [185625 PKR] | 185,625 |
| B1300 |  | Form Work | 4d | 2020-11-29 | 2020-12-03 | B1290 | -0.3d | 0d | Cost Loading [91375 PKR] | 91,375 |
| B1310 |  | Footing Concrete R.C.C (C20) | 4d | 2020-12-03 | 2020-12-07 | B1300 | -0.3d | 0d | Cost Loading [34800 PKR] | 34,800 |
| B1320 |  | Foundation beam R.C.C (C20) | 4d | 2020-12-07 | 2020-12-11 | B1310 | -0.3d | 0d | Cost Loading [44400 PKR] | 44,400 |
| B1330 |  | Backfilling | 4d | 2020-12-11 | 2020-12-15 | B1320 | 3.7d | 4d | Cost Loading [19350 PKR] | 19,350 |
| B1340 |  | Flooring R.C.C (C20) | 4d | 2020-12-11 | 2020-12-15 | B1320 | -0.3d | 0d | Cost Loading [20000 PKR] | 20,000 |
| B1350 |  | Bitumen Coating | 4d | 2020-12-15 | 2020-12-19 | B1340 | -0.3d | 0d | Cost Loading [43000 PKR] | 43,000 |
|  | 5 | **Section 4-4** |  | 2020-11-17 | 2020-12-19 |  |  |  |  |  |
| B1360 |  | Excavation | 4d | 2020-11-17 | 2020-11-21 | B1000 SS | -0.3d | 0d | Cost Loading [30450 PKR] | 30,450 |
| B1370 |  | P.C.C Concrete 1:4:8 | 4d | 2020-11-21 | 2020-11-25 | B1360 | -0.3d | 0d | Cost Loading [23887.5 PKR] | 23,887.5 |
| B1380 |  | Reinforcement 60 Grade | 4d | 2020-11-25 | 2020-11-29 | B1370 | -0.3d | 0d | Cost Loading [259875 PKR] | 259,875 |
| B1390 |  | Form Work | 4d | 2020-11-29 | 2020-12-03 | B1380 | -0.3d | 0d | Cost Loading [127925 PKR] | 127,925 |
| B1400 |  | Footing Concrete R.C.C (C20) | 4d | 2020-12-03 | 2020-12-07 | B1390 | -0.3d | 0d | Cost Loading [48720 PKR] | 48,720 |
| B1410 |  | Foundation beam R.C.C (C20) | 4d | 2020-12-07 | 2020-12-11 | B1400 | -0.3d | 0d | Cost Loading [62160 PKR] | 62,160 |
| B1420 |  | Backfilling | 4d | 2020-12-11 | 2020-12-15 | B1410 | 3.7d | 4d | Cost Loading [27090 PKR] | 27,090 |
| B1430 |  | Flooring R.C.C (C20) | 4d | 2020-12-11 | 2020-12-15 | B1410 | -0.3d | 0d | Cost Loading [28000 PKR] | 28,000 |
| B1440 |  | Bitumen Coating | 4d | 2020-12-15 | 2020-12-19 | B1430 | -0.3d | 0d | Cost Loading [60200 PKR] | 60,200 |

| ID | WBS | Activity | Type | Duration | Start | Finish | Predecessors | Total float | Free float | Resources | Cost |
| --- | --- | --- | --- | --- | --- | --- | --- | --- | --- | --- | --- |
|  | 6 | **Air Duct 7-7** |  |  | 2020-11-17 | 2020-12-03 |  |  |  |  |  |
| B1450 |  | Excavation |  | 2d | 2020-11-17 | 2020-11-19 | B1000 SS | 15.7d | 0d | Cost Loading [4350 PKR] | 4,350 |
| B1460 |  | P.C.C Concrete 1:4:8 |  | 2d | 2020-11-19 | 2020-11-21 | B1450 | 15.7d | 0d | Cost Loading [3412.5 PKR] | 3,412.5 |
| B1470 |  | Reinforcement 60 Grade |  | 2d | 2020-11-21 | 2020-11-23 | B1460 | 15.7d | 0d | Cost Loading [37125 PKR] | 37,125 |
| B1480 |  | Form Work |  | 2d | 2020-11-23 | 2020-11-25 | B1470 | 15.7d | 0d | Cost Loading [18275 PKR] | 18,275 |
| B1490 |  | Footing Concrete R.C.C (C20) |  | 2d | 2020-11-25 | 2020-11-27 | B1480 | 15.7d | 0d | Cost Loading [6960 PKR] | 6,960 |
| B1500 |  | Foundation beam R.C.C (C20) |  | 2d | 2020-11-27 | 2020-11-29 | B1490 | 15.7d | 0d | Cost Loading [8880 PKR] | 8,880 |
| B1510 |  | Backfilling |  | 2d | 2020-11-29 | 2020-12-01 | B1500 | 17.7d | 18d | Cost Loading [3870 PKR] | 3,870 |
| B1520 |  | Flooring R.C.C (C20) |  | 2d | 2020-11-29 | 2020-12-01 | B1500 | 15.7d | 0d | Cost Loading [4000 PKR] | 4,000 |
| B1530 |  | Bitumen Coating |  | 2d | 2020-12-01 | 2020-12-03 | B1520 | 15.7d | 16d | Cost Loading [8600 PKR] | 8,600 |
|  | 7 | **Project Completion /Hand Over** |  |  | 2020-12-19 | 2020-12-19 |  |  |  |  |  |
| A1040 |  | Project Hand Over | milestone | 0d | 2020-12-19 | 2020-12-19 | B1530, B1440, B1350, B1260, B1170, B1080 | -0.3d | 0d |  |  |
